# Proyect1

Schedule from MS Project, 2009-10-05 to 2010-08-06.

## Calendars

- Estándar: Mon-Fri 09:00-13:00, 15:00-19:00; Sat-Sun off. Exceptions (off unless hours are given): 2010-01-30 09:00-13:00, 15:00-19:00.

## Resources

| Resource | Group |
| --- | --- |
| Dr. Antonio Carlos Jiménez (Resp. Tec.) | Universidad "A" |
| Dr. Raúl Javier Benitez | Centro de Investigación "A" |
| Dr. Mario Cruz Nieble | Facultad "A" |
| Dr. Tomás Iriarte Galvez | Universidad "B" |
| Lic. Tesista 1 | Facultad "A" |
| Lic. Tesista 2 | Facultad "A" |
| Lic. Tesista 3 | Facultad "A" |
| Lic. Tesista 4 | Facultad "A" |
| Lic. Tesista 5 | Facultad "A" |
| Lic. Tesista 6 | Universidad "B" |
| Maestría Tesista 2 | Universidad "B" |
| Maestría Tesista 2 | Universidad "B" |
| Lic. Tesista 7 | Universidad "B" |
| Maestría Tesista 1 | Universidad "B" |

## Schedule

| ID | WBS | Task | Duration | Start | Finish | Predecessors | Total slack | Free slack | Constraint | Text1 | Text3 | Text4 |
| --- | --- | --- | --- | --- | --- | --- | --- | --- | --- | --- | --- | --- |
| 1 | 1 | PRODUCCIÓN DE ETANOL A PARTIR DE ALGAS | 1d | 2010-01-01 | 2010-01-01 |  | 156d |  | start no earlier than 2010-01-01 |  |  |  |
| 2 | 2 | **Inicio** | 221d? | 2009-10-05 | 2010-08-06 |  | 0d |  |  |  |  |  |
| 3 | 2.1 | **ETAPA 1 - preliminar y preparaciones** | 86d? | 2009-10-05 | 2010-01-30 |  | 126d |  |  |  |  |  |
| 4 | 2.1.1 | Preparación de material | 11d | 2009-10-05 | 2009-10-19 |  | 126d | 0d | start no earlier than 2009-10-05 | M1 | ACJ | 2,000 |
| 5 | 2.1.2 | Identificación y clasificación de microorganismos | 10d | 2009-10-20 | 2009-11-02 | 4 | 200d |  |  | M1 | ACJ, RJB | 2,500 |
| 6 | 2.1.3 | **Preparación y reproducción de cultivos** | 2d? | 2010-01-29 | 2010-01-30 | 4 | 135d |  |  |  |  |  |
| 7 | 2.1.3.1 | Clase A | 1d? | 2010-01-29 | 2010-01-29 |  | 135d | 0d | start no earlier than 2010-01-29 | M2, M1 | ACJ,RJB | 3,100 |
| 8 | 2.1.3.2 | Clase B | 1d? | 2010-01-30 | 2010-01-30 | 7 | 135d |  | finish no earlier than 2010-01-29 | M2 | ACJ,RJB | 1,900 |
| 9 | 2.2 | **Etapa 2 - Operación y validación** | 48d? | 2010-02-01 | 2010-04-07 |  | 51d |  |  |  |  |  |
| 10 | 2.2.1 | Variación de parámetros | 3d | 2010-02-01 | 2010-02-03 |  | 128d | 0d | start no earlier than 2010-02-01 | M3 | RJB,MCN | 500 |
| 11 | 2.2.2 | Evaluación de parámetros | 1d? | 2010-02-04 | 2010-02-04 | 10 | 128d | 0d |  | M3 | RJB,MCN | 1,658 |
| 12 | 2.2.3 | Selección y definición de parámetros a controlar | 3d | 2010-02-05 | 2010-02-09 | 11 | 128d |  |  | M3 | RJB,MCN | 1,260 |
| 13 | 2.2.4 | **Obtención de Licencia** | 7d? | 2010-02-10 | 2010-02-18 |  | 44d |  |  |  |  |  |
| 14 | 2.2.4.1 | Benchmark | 3d | 2010-02-10 | 2010-02-12 | 4 | 44d | 0d | start no earlier than 2010-02-10 | M4 | ACJ,MCN | 1,100 |
| 15 | 2.2.4.2 | Marco legal | 4d | 2010-02-15 | 2010-02-18 |  | 121d |  | start no earlier than 2010-02-15 | M4 | ACJ,MCN | 900 |
| 16 | 2.2.4.3 | **Documento preliminar** | 2d? | 2010-02-15 | 2010-02-16 | 14 | 87d | 0d |  |  |  |  |
| 17 | 2.2.4.3.1 | Objetivos y alcances | 1d? | 2010-02-15 | 2010-02-15 |  | 87d | 0d |  | M4 | ACJ,TIG | 300 |
| 18 | 2.2.4.3.2 | Unidad funcional | 1d? | 2010-02-16 | 2010-02-16 | 17 | 87d |  |  | M4 | ACJ,TIG | 150 |
| 19 | 2.2.5 | **Formato de Proceso** | 36d? | 2010-02-17 | 2010-04-07 | 16 | 87d |  |  |  |  |  |
| 20 | 2.2.5.1 | **Fronteras del sistema** | 1d? | 2010-02-17 | 2010-02-17 |  | 87d |  |  |  |  |  |
| 21 | 2.2.5.1.1 | Descripción general | 1d? | 2010-02-17 | 2010-02-17 | 16 | 122d |  |  |  |  |  |
| 22 | 2.2.5.1.2 | Fronteras específicas | 1d? | 2010-02-17 | 2010-02-17 | 16 | 122d |  |  |  |  |  |
| 23 | 2.2.5.1.3 | Importación de energía | 1d? | 2010-02-17 | 2010-02-17 | 16 | 87d | 0d |  |  |  |  |
| 24 | 2.2.5.2 | Definición de procesos unitarios | 3d | 2010-02-18 | 2010-02-22 | 23 | 87d | 0d |  | M5 | ACJ,TIG | 1,500 |

Notes:
- 5: Text2: Informe de la colección e interpretación del paquete completo de microorganismos
- 7: Text2: Informe de Caracterización de microorganismos clase A
- 8: Text2: Informe de Caracterización de microorganismos clase B
- 10: Text2: Informe de Variación de Parámetros
- 11: Text2: Informe de evaluación de Parámetros
- 12: Text2: Informe de selección y definición de parámetros, Publicación en la revista "Revista 1"

| ID | WBS | Task | Duration | Start | Finish | Predecessors | Total slack | Free slack | Constraint | Text1 | Text3 | Text4 | Text2 |
| --- | --- | --- | --- | --- | --- | --- | --- | --- | --- | --- | --- | --- | --- |
| 25 | 2.2.5.3 | **Tipos de información** | 3d? | 2010-02-23 | 2010-02-25 |  | 116d |  |  |  |  |  |  |
| 26 | 2.2.5.3.1 | Información primaria | 1d? | 2010-02-23 | 2010-02-23 | 24 | 118d |  |  |  |  |  |  |
| 27 | 2.2.5.3.2 | Información secundaria | 1d? | 2010-02-23 | 2010-02-23 | 24 | 118d |  |  |  |  |  |  |
| 28 | 2.2.5.3.3 | Unidades | 1d? | 2010-02-23 | 2010-02-23 | 24 | 118d |  |  |  |  |  |  |
| 29 | 2.2.5.3.4 | Tecnologías | 3d | 2010-02-23 | 2010-02-25 | 24 | 116d |  |  |  |  |  |  |
| 30 | 2.2.5.4 | Requerimientos en la calidad de la información | 1d? | 2010-02-23 | 2010-02-23 | 24 | 118d |  |  | M4 | ACJ,TIG | 1,200 |  |
| 31 | 2.2.5.5 | Flujos elementales | 30d | 2010-02-23 | 2010-04-05 | 24 | 87d | 0d |  | M4 | ACJ,TIG | 980 |  |
| 32 | 2.2.5.6 | Reglas de asignación | 2d | 2010-04-06 | 2010-04-07 | 31 | 87d |  |  | M4 | ACJ | 2,000 | Obtención de licencia |
| 33 | 2.3 | **Etapa 3 - Proceso de Fermentación** | 86d? | 2010-04-09 | 2010-08-06 |  | 0d |  |  |  |  |  |  |
| 34 | 2.3.1 | **Fermentación** | 41d | 2010-04-09 | 2010-06-04 | 14 | 5d |  |  |  |  |  |  |
| 35 | 2.3.1.1 | Fermentación de hidrolizados | 20d | 2010-04-09 | 2010-05-06 |  | 5d | 0d | start no earlier than 2010-04-09 | M5 | ACJ,RJB | 1,000 | Informe de fermentación de hidrolizados |
| 36 | 2.3.1.2 | Fermentación de cultivos mixtos | 21d | 2010-05-07 | 2010-06-04 | 35 | 45d |  |  | M5 | ACJ,RJB | 1,400 | Informe de fermentación de cultivos mixtos |
| 37 | 2.3.2 | **Estudios** | 61d | 2010-05-07 | 2010-07-30 |  | 5d |  |  |  |  |  |  |
| 38 | 2.3.2.1 | Estudio de Ingeniería del proceso | 21d | 2010-05-07 | 2010-06-04 | 35 | 5d | 0d |  | M5 | ACJ,RJB | 1,200 | Pulblicación en revista "Revista 2", Tesis de Licenciatura |
| 39 | 2.3.2.2 | Estudio Financiero | 18d | 2010-06-07 | 2010-06-30 | 38 | 5d | 0d |  | M5 | ACJ,RJB | 1,150 | Pulblicación en revista "Revista 2", Tesis de Maestría |
| 40 | 2.3.2.3 | Estudio de escalamiento | 22d | 2010-07-01 | 2010-07-30 | 39 | 5d |  |  | M5 | ACJ,RJB | 870 | Pulblicación en revista "Revista 2", Tesis de Doctorado |
| 41 | 2.3.3 | Informe final | 3d? | 2010-08-04 | 2010-08-06 |  | 0d |  | start no earlier than 2010-08-04 | M6 | ACJ,RJB | 3,500 | Informe final, entrevista con empresarios |
